# TextureSync

Schedule from Planner, 2019-03-23 to 2019-05-25.
AI4 - HS Offenburg

## Calendars

- Vorgabe: Mon off; Tue-Wed 08:00-12:00, 13:00-17:00; Thu-Fri off; Sat 08:00-12:00, 13:00-17:00; Sun off.

## Resources

| Resource |
| --- |
| Robin |
| Hendrik |
| Jannik |
| Lukas |

## Schedule

| ID | WBS | Task | Type | Duration | Start | Finish | Predecessors | Complete | Resources | Work |
| --- | --- | --- | --- | --- | --- | --- | --- | --- | --- | --- |
| 1 | 1 | **Definition** |  |  | 2019-03-23 | 2019-04-03 |  |  |  | 80h |
| 2 | 1.1 | Charta [M] |  |  | 2019-03-23 | 2019-03-23 |  | 100% |  | 8h |
| 3 | 1.2 | Lastenheft [M] |  |  | 2019-03-23 | 2019-03-27 |  | 100% |  | 24h |
| 4 | 1.3 | Pflichtenheft [M] |  |  | 2019-03-30 | 2019-04-03 | 3 | 100% | Lukas | 24h |
| 5 | 1.4 | Risikoanalyse [M] |  |  | 2019-03-30 | 2019-04-03 | 3 | 100% | Robin [50%]; Hendrik [50%] | 24h |
| 6 | 2 | **Plannung** |  |  | 2019-04-06 | 2019-04-13 |  |  |  | 120h |
| 7 | 2.1 | **Grobdesign [M]** |  |  | 2019-04-06 | 2019-04-06 |  |  |  | 8h |
| 8 | 2.1.1 | Architektur festlegen |  |  | 2019-04-06 | 2019-04-06 | 5 |  | Lukas | 8h |
| 9 | 2.2 | **Feindesign [M]** |  |  | 2019-04-09 | 2019-04-13 |  |  |  | 80h |
| 10 | 2.2.1 | 3D Test auf Kotlin + ChipView Test |  |  | 2019-04-09 | 2019-04-13 | 8 |  | Jannik | 24h |
| 11 | 2.2.2 | Netzwerk-Protokoll definieren |  |  | 2019-04-09 | 2019-04-13 | 8 | 90% | Robin | 24h |
| 12 | 2.2.3 | Mockups |  |  | 2019-04-09 | 2019-04-10 | 8 | 100% | Jannik | 16h |
| 13 | 2.2.4 | Wie Metadaten filtern? |  |  | 2019-04-09 | 2019-04-10 | 8 |  | Robin | 16h |
| 14 | 2.3 | Task zuweisen |  |  | 2019-04-09 | 2019-04-09 | 8 | 100% |  | 8h |
| 15 | 2.4 | Mastertestplan [M] |  |  | 2019-04-09 | 2019-04-13 | 8 | 20% | Hendrik | 24h |
| 16 | 3 | End of Design | milestone | 0d | 2019-04-13 | 2019-04-13 | 11, 10 |  |  |  |
| 17 | 4 | **Realisation** |  |  | 2019-04-16 | 2019-04-24 | 16 |  |  | 200h |
| 18 | 4.1 | **Einrichtung von Tests** |  |  | 2019-04-16 | 2019-04-16 | 11 |  |  | 16h |
| 19 | 4.1.1 | Client Tests |  |  | 2019-04-16 | 2019-04-16 |  |  |  | 8h |
| 20 | 4.1.2 | Server Tests |  |  | 2019-04-16 | 2019-04-16 |  |  |  | 8h |
| 21 | 4.2 | **Client** |  |  | 2019-04-16 | 2019-04-20 | 11 |  |  | 104h |
| 22 | 4.2.1 | **UI** |  |  | 2019-04-16 | 2019-04-20 |  |  |  | 80h |
| 23 | 4.2.1.1 | Previews |  |  | 2019-04-16 | 2019-04-20 |  |  |  | 24h |
| 24 | 4.2.1.2 | Filter Kontrollstrukturen |  |  | 2019-04-16 | 2019-04-20 |  |  |  | 24h |
| 25 | 4.2.1.3 | 3D Visualisierung |  |  | 2019-04-16 | 2019-04-17 |  |  |  | 16h |
| 26 | 4.2.1.4 | Dateien hinzufügen |  |  | 2019-04-16 | 2019-04-16 |  |  |  | 8h |
| 27 | 4.2.1.5 | Dateien lokal abspeichern |  |  | 2019-04-16 | 2019-04-16 |  |  |  | 8h |
| 28 | 4.2.2 | Grund Architektur |  |  | 2019-04-16 | 2019-04-20 |  |  |  | 24h |

| ID | WBS | Task | Type | Duration | Start | Finish | Predecessors | Work |
| --- | --- | --- | --- | --- | --- | --- | --- | --- |
| 29 | 4.3 | **Server** |  |  | 2019-04-16 | 2019-04-24 | 11 | 48h |
| 30 | 4.3.1 | Dateien speichern/verwalten |  |  | 2019-04-16 | 2019-04-24 |  | 40h |
| 31 | 4.3.2 | Filter implementieren |  |  | 2019-04-16 | 2019-04-16 |  | 8h |
| 32 | 4.4 | Protokoll implementieren |  |  | 2019-04-16 | 2019-04-23 |  | 32h |
| 33 | 5 | End of Implementation | milestone | 0d | 2019-04-24 | 2019-04-24 | 29, 21, 18 |  |
| 34 | 6 | **Abnahme** |  |  | 2019-04-27 | 2019-05-25 |  | 104h |
| 35 | 6.1 | Modultests [M] |  |  | 2019-04-27 | 2019-05-04 | 33 | 32h |
| 36 | 6.2 | Integrationstests [M] |  |  | 2019-05-07 | 2019-05-14 | 35 | 32h |
| 37 | 6.3 | Systemtests [M] |  |  | 2019-05-15 | 2019-05-22 | 36 | 32h |
| 38 | 6.4 | Akzeptanztest [M] |  |  | 2019-05-25 | 2019-05-25 | 37 | 8h |
